# USB Flash Drive_03152012

How a schedule from MS Project changed from version to version. A marks actual dates.

## Version 1 (saved 2012-03-15, file USB Flash Drive_03152012.mpp)

| ID | WBS | Task | Duration | Start | Finish | Predecessors | Complete | Total float |
| --- | --- | --- | --- | --- | --- | --- | --- | --- |
| 1 | 1 | **USB Flash Drive** | 132d | 2012-02-23 A | 2012-08-24 |  | 12% | 0d |
| 2 | 1.1 | **Phase 0 (Business Case)** | 5d | 2012-02-23 A | 2012-02-29 A |  | 100% |  |
| 3 |  | MRD | 1d | 2012-02-23 A | 2012-02-23 A |  | 100% |  |
| 4 |  | Marketing Review | 1d | 2012-02-24 A | 2012-02-24 A | 3 | 100% |  |
| 5 |  | Marketing Approval | 0d | 2012-02-24 A | 2012-02-24 A | 4 | 100% |  |
| 6 | 1.1.4 | **Phase 0 Gate** | 1d | 2012-02-29 A | 2012-02-29 A |  | 100% |  |
| 7 |  | Review & approve | 1d | 2012-02-29 A | 2012-02-29 A | 5 | 100% |  |
| 8 | 1.2 | **Phase 1 (Planning)** | 74d | 2012-03-01 A | 2012-06-12 A |  | 100% |  |
| 9 |  | Internal Kick Off Meeting | 1d | 2012-03-01 A | 2012-03-01 A | 7 | 100% |  |
| 10 | 1.2.2 | **Requirements** | 65d | 2012-03-02 A | 2012-05-31 A |  | 100% |  |
| 11 | 1.2.2.1 | **PRD** | 7d | 2012-03-07 A | 2012-03-15 A |  | 100% |  |
| 12 |  | Generate PRD | 5d | 2012-03-07 A | 2012-03-13 A | 9 | 100% |  |
| 13 |  | Internal review | 2d | 2012-03-14 A | 2012-03-15 A | 12 | 100% |  |
| 14 |  | Internal approval | 0d | 2012-03-15 A | 2012-03-15 A | 13 | 100% |  |
| 15 | 1.2.2.2 | **Industrial Design** | 17d | 2012-03-02 A | 2012-03-26 A |  | 100% |  |
| 16 |  | Contractor Selection | 2d | 2012-03-02 A | 2012-03-22 A | 9 | 100% |  |
| 17 |  | Initial Industrial Design | 1d | 2012-03-23 A | 2012-03-23 A | 16 | 100% |  |
| 18 |  | Review | 1d | 2012-03-26 A | 2012-03-26 A | 17 | 100% |  |
| 19 | 1.2.2.3 | **Outsourcing - Suppliers/Partners Selection** | 65d | 2012-03-02 A | 2012-05-31 A |  | 100% |  |
| 20 | 1.2.2.3.1 | **RFQ process** | 65d | 2012-03-02 A | 2012-05-31 A |  | 100% |  |
| 21 |  | Generate List of Potential Partners | 1d | 2012-03-02 A | 2012-03-02 A | 9 | 100% |  |
| 22 |  | Suppliers/Partners Review | 4d | 2012-03-05 A | 2012-03-27 A | 21 | 100% |  |
| 23 |  | Issue RFQs including PRD | 1d | 2012-03-28 A | 2012-03-28 A | 14, 22 | 100% |  |
| 24 | 1.2.2.3.1.4 | **ODM Quote completed** | 34d | 2012-03-29 A | 2012-05-15 A |  | 100% |  |
| 25 |  | Review Financial Terms | 1d | 2012-03-29 A | 2012-03-29 A | 23 | 100% |  |
| 26 |  | Review Technical Capabilities | 2d | 2012-03-30 A | 2012-05-14 A | 23 | 100% |  |
| 27 |  | Review Production Capabilities | 1d | 2012-03-29 A | 2012-03-29 A | 23 | 100% |  |
| 28 |  | ODM/CM Selection | 1d | 2012-05-15 A | 2012-05-15 A | 25, 26, 27 | 100% |  |
| 29 |  | Supplier Kick off Meeting | 2d | 2012-05-16 A | 2012-05-29 A | 14, 18, 28 | 100% |  |
| 30 | 1.2.2.3.1.6 | **Contractor Quote Completed** | 4d | 2012-03-02 A | 2012-03-07 A |  | 100% |  |
| 31 | 1.2.2.3.1.6.1 | **SOW** | 3d | 2012-03-02 A | 2012-03-06 A |  | 100% |  |
| 32 |  | Generate SOW | 3d | 2012-03-02 A | 2012-03-06 A | 9 | 100% |  |
| 33 |  | Approved | 0d | 2012-03-06 A | 2012-03-06 A | 32 | 100% |  |
| 34 |  | Review | 1d | 2012-03-07 A | 2012-03-07 A | 33 | 100% |  |
| 35 |  | Contractor Selection | 0d | 2012-03-07 A | 2012-03-07 A | 34 | 100% |  |
| 36 | 1.2.2.3.1.7 | **Mechanical Manufacturing (Shell/Housing)** | 2d | 2012-05-30 A | 2012-05-31 A |  | 100% |  |
| 37 |  | Review | 1d | 2012-05-30 A | 2012-05-30 A | 14, 29 | 100% |  |
| 38 |  | Contractor Selection | 0d | 2012-05-30 A | 2012-05-30 A | 37 | 100% |  |
| 39 |  | Kick off Meeting | 1d | 2012-05-31 A | 2012-05-31 A | 38 | 100% |  |
| 40 | 1.2.3 | **Schedule** | 58d | 2012-03-19 A | 2012-06-06 A |  | 100% |  |
| 41 |  | Set-up | 3d | 2012-03-19 A | 2012-03-28 A | 14 | 100% |  |
| 42 |  | Review | 3d | 2012-06-01 A | 2012-06-06 A | 29, 39, 41 | 100% |  |
| 43 |  | Approval | 0d | 2012-06-06 A | 2012-06-06 A | 42 | 100% |  |
| 44 | 1.2.4 | **BOMs/Routings** | 8d | 2012-05-17 A | 2012-05-28 A |  | 100% |  |
| 45 |  | Engineering PN Generation | 1d | 2012-05-18 A | 2012-05-18 A | 14 | 100% |  |
| 46 |  | Marketing BOM (SKU) Initial Status | 1d | 2012-05-28 A | 2012-05-28 A | 14 | 100% |  |
| 47 |  | Manufacturing BOM (Technical) Initial Status | 1d | 2012-05-17 A | 2012-05-17 A | 14 | 100% |  |
| 48 | 1.2.5 | **Financial Model** | 72d | 2012-03-01 A | 2012-06-08 A |  | 100% |  |
| 49 |  | Product Development Budget | 1d | 2012-06-07 A | 2012-06-07 A | 28, 39, 43 | 100% |  |
| 50 |  | Product Cost | 1d | 2012-05-29 A | 2012-05-29 A | 28, 44 | 100% |  |
| 51 |  | Marketing Plan | 1d | 2012-03-01 A | 2012-03-01 A | 5 | 100% |  |
| 52 |  | ROI/Revenue Projection | 1d | 2012-06-08 A | 2012-06-08 A | 47, 49, 50, 51 | 100% |  |
| 53 | 1.2.6 | **Phase 1 Gate** | 2d | 2012-06-11 A | 2012-06-12 A |  | 100% |  |
| 54 |  | Review & Approval | 2d | 2012-06-11 A | 2012-06-12 A | 14, 43, 52 | 100% |  |
| 55 | 1.3 | **Phase 2 (Development)** | 132d | 2012-02-23 | 2012-08-24 |  |  | 0d |
| 56 | 1.3.1 | **Documentation** | 72d | 2012-03-02 | 2012-06-11 |  |  | 23d |
| 57 | 1.3.1.1 | **Final Product spec to suppliers / Vendors** | 3d | 2012-03-21 | 2012-03-23 |  |  | 10d |
| 58 |  | Develop Spec | 1d | 2012-03-21 | 2012-03-21 | 14 |  | 10d |
| 59 |  | Prepare document | 1d | 2012-03-22 | 2012-03-22 | 58 |  | 10d |
| 60 |  | Review & Approve | 1d | 2012-03-23 | 2012-03-23 | 59 |  | 10d |
| 61 | 1.3.1.2 | **Packaging Plan** | 7d | 2012-03-02 | 2012-03-12 |  |  | 69d |
| 62 |  | Define requirements | 1d | 2012-03-02 | 2012-03-02 | 9 |  | 69d |
| 63 |  | Prepare document | 1d | 2012-03-05 | 2012-03-05 | 62 |  | 69d |
| 64 |  | Publish Plan | 4d | 2012-03-06 | 2012-03-09 | 63 |  | 69d |
| 65 |  | Review & Approved | 1d | 2012-03-12 | 2012-03-12 | 64 |  | 69d |
| 66 | 1.3.1.3 | **Product Qual Plan** | 46d | 2012-03-16 | 2012-05-18 |  |  | 65d |
| 67 | 1.3.1.3.1 | **Compatibility Test Plan** | 46d | 2012-03-16 | 2012-05-18 |  |  | 65d |
| 68 |  | Prepare document | 1d | 2012-03-16 | 2012-03-16 | 14 |  | 65d |
| 69 |  | Publish Plan | 1d | 2012-03-19 | 2012-03-19 | 68 |  | 65d |
| 70 |  | Review & Approval | 2d | 2012-03-21 | 2012-05-18 | 69 |  | 65d |

| ID | WBS | Task | Duration | Start | Finish | Predecessors | Total float |
| --- | --- | --- | --- | --- | --- | --- | --- |
| 71 | 1.3.1.3.2 | **Reliability Plan** | 3d | 2012-03-16 | 2012-03-20 |  | 108d |
| 72 |  | Prepare document | 1d | 2012-03-16 | 2012-03-16 | 14 | 108d |
| 73 |  | Publish Plan | 1d | 2012-03-19 | 2012-03-19 | 72 | 108d |
| 74 |  | Review & Approval | 1d | 2012-03-20 | 2012-03-20 | 73 | 108d |
| 75 | 1.3.1.3.3 | **Compliance/Certification Plan** | 3d | 2012-03-16 | 2012-03-20 |  | 108d |
| 76 |  | Prepare document | 1d | 2012-03-16 | 2012-03-16 | 14 | 108d |
| 77 |  | Publish Plan | 1d | 2012-03-19 | 2012-03-19 | 76 | 108d |
| 78 |  | Review & Approval | 1d | 2012-03-20 | 2012-03-20 | 77 | 108d |
| 79 | 1.3.1.4 | **Packaging Qual Plan** | 5d | 2012-03-16 | 2012-03-22 |  | 106d |
| 80 |  | Prepare document | 1d | 2012-03-16 | 2012-03-16 | 14 | 106d |
| 81 |  | Publish Plan | 3d | 2012-03-19 | 2012-03-21 | 80 | 106d |
| 82 |  | Review & Approval | 1d | 2012-03-22 | 2012-03-22 | 81 | 106d |
| 83 | 1.3.1.5 | **QA Plan (IQC, OQC, OQRM, etc)** | 3d | 2012-03-16 | 2012-03-20 |  | 108d |
| 84 |  | Prepare document | 1d | 2012-03-16 | 2012-03-16 | 14 | 108d |
| 85 |  | Publish Plan | 1d | 2012-03-19 | 2012-03-19 | 84 | 108d |
| 86 |  | Review & Approval | 1d | 2012-03-20 | 2012-03-20 | 85 | 108d |
| 87 | 1.3.1.6 | **Production Plan** | 3d | 2012-03-16 | 2012-03-20 |  | 46d |
| 88 |  | Prepare document | 1d | 2012-03-16 | 2012-03-16 | 14 | 46d |
| 89 |  | Publish Plan | 1d | 2012-03-19 | 2012-03-19 | 88 | 46d |
| 90 |  | Review & Approval | 1d | 2012-03-20 | 2012-03-20 | 89 | 46d |
| 91 | 1.3.1.7 | **Production Test Plan** | 3d | 2012-03-16 | 2012-03-20 |  | 46d |
| 92 |  | Prepare document | 1d | 2012-03-16 | 2012-03-16 | 14 | 46d |
| 93 |  | Publish Plan | 1d | 2012-03-19 | 2012-03-19 | 92 | 46d |
| 94 |  | Review & Approval | 1d | 2012-03-20 | 2012-03-20 | 93 | 46d |
| 95 | 1.3.1.8 | **Product Test** | 59d | 2012-03-21 | 2012-06-11 |  | 54d |
| 96 |  | Product Test Specifications | 1d | 2012-05-31 | 2012-05-31 | 60 | 44d |
| 97 |  | Test Equipment | 2d | 2012-06-01 | 2012-06-11 | 90, 96 | 44d |
| 98 | 1.3.1.8.3 | **Pre-lim Process** | 3d | 2012-03-22 | 2012-03-26 |  | 109d |
| 99 |  | Publish Plan | 2d | 2012-03-22 | 2012-03-26 | 94 | 109d |
| 100 |  | Review & Approval | 0d | 2012-03-26 | 2012-03-26 | 99 | 109d |
| 101 | 1.3.1.8.4 | **Pre-lim Program** | 3d | 2012-03-21 | 2012-03-23 |  | 110d |
| 102 |  | Publish Plan | 2d | 2012-03-21 | 2012-03-23 | 94 | 110d |
| 103 |  | Review & Approval | 0d | 2012-03-23 | 2012-03-23 | 102 | 110d |
| 104 |  | All qual plans prepared | 0d | 2012-03-22 | 2012-03-22 | 59, 63, 68, 72, 76, 80, 84, 88, 92 | 111d |
| 105 |  | All Qual Plans Approved | 1d | 2012-05-21 | 2012-05-21 | 60, 65, 70, 74, 78, 82, 86, 90, 94 | 65d |
| 106 | 1.3.2 | **PCB** | 44d | 2012-03-26 | 2012-05-24 |  | 10d |
| 107 |  | Schematic Design | 8d | 2012-03-26 | 2012-04-04 | 60 | 10d |
| 108 |  | PCB Layout | 22d | 2012-04-05 | 2012-05-04 | 107 | 10d |
| 109 |  | Design Review | 3d | 2012-05-07 | 2012-05-09 | 108 | 10d |
| 110 |  | Design For Manufacturability (DFM) - PCB | 2d | 2012-05-10 | 2012-05-11 | 90, 94, 109 | 10d |
| 111 |  | Approve | 1d | 2012-05-14 | 2012-05-14 | 109, 110 | 10d |
| 112 |  | PCB Fabrication | 8d | 2012-05-15 | 2012-05-24 | 111 | 10d |
| 113 | 1.3.3 | **Housing** | 73d | 2012-03-16 | 2012-06-26 |  | 7d |
| 114 | 1.3.3.1 | **Industrial Design** | 16d | 2012-03-27 | 2012-04-17 |  | 0d |
| 115 |  | Review & Approval | 16d | 2012-03-27 | 2012-04-17 | 18 | 0d |
| 116 | 1.3.3.2 | **Mechanical Design** | 12d | 2012-04-18 | 2012-05-03 |  | 0d |
| 117 |  | 3D CAD | 5d | 2012-04-18 | 2012-04-24 | 115 | 0d |
| 118 |  | Design Review | 1d | 2012-04-25 | 2012-04-25 | 117 | 0d |
| 119 |  | DFM | 2d | 2012-04-26 | 2012-04-27 | 118 | 0d |
| 120 |  | Approve | 0d | 2012-04-27 | 2012-04-27 | 119 | 0d |
| 121 |  | Part Drawings | 4d | 2012-04-30 | 2012-05-03 | 120 | 0d |
| 122 | 1.3.3.3 | **Tooling** | 68d | 2012-03-16 | 2012-06-19 |  | 33d |
| 123 |  | Tooling Design | 2d | 2012-04-30 | 2012-05-01 | 120 | 2d |
| 124 |  | Pre-lim tooling (T0) | 20d | 2012-05-04 | 2012-05-31 | 121, 123 | 0d |
| 125 |  | Final tooling (T1) | 13d | 2012-06-01 | 2012-06-19 | 124 | 0d |
| 126 | 1.3.3.3.4 | **Capacity Plan** | 1d | 2012-05-02 | 2012-05-02 |  | 82d |
| 127 |  | Review & Approval | 1d | 2012-05-02 | 2012-05-02 | 123 | 82d |
| 128 | 1.3.3.3.5 | **Ramp-up Plan** | 1d | 2012-03-16 | 2012-03-16 |  | 115d |
| 129 |  | Review & Approval | 1d | 2012-03-16 | 2012-03-16 | 14 | 115d |
| 130 |  | Housing Approved | 3d | 2012-06-22 | 2012-06-26 | 120, 125 | 0d |
| 131 | 1.3.4 | **Packaging** | 88d | 2012-02-23 | 2012-06-25 |  | 44d |
| 132 | 1.3.4.1 | **Dummy** | 14d | 2012-05-04 | 2012-05-23 |  | 35d |
| 133 |  | Dummy Unit /Evaluate Button Functionality | 10d | 2012-05-04 | 2012-05-17 | 121 | 35d |
| 134 |  | Dummy Review and Approval | 4d | 2012-05-18 | 2012-05-23 | 133 | 35d |
| 135 | 1.3.4.2 | **Clamshell** | 37d | 2012-05-04 | 2012-06-25 |  | 34d |
| 136 |  | Clamshell Design | 3d | 2012-05-21 | 2012-05-23 | 65, 120 | 35d |
| 137 |  | Clamshell Prototype Tool 20 units | 7d | 2012-05-24 | 2012-06-01 | 134, 136 | 35d |
| 138 |  | FAI/Review & approval (Shipping included) | 4d | 2012-06-06 | 2012-06-11 | 137 | 33d |
| 139 |  | Production Tool 20 units | 6d | 2012-06-12 | 2012-06-19 | 138 | 33d |
| 140 |  | FAI/Review & Approval | 4d | 2012-06-20 | 2012-06-25 | 139 | 33d |

| ID | WBS | Task | Duration | Start | Finish | Predecessors | Total float |
| --- | --- | --- | --- | --- | --- | --- | --- |
| 141 | 1.3.4.2.6 | **Insert** | 15d | 2012-05-04 | 2012-05-24 |  | 56d |
| 142 |  | Clamshell Insert Design | 4d | 2012-05-04 | 2012-05-09 | 65, 120 | 56d |
| 143 |  | Clamshell Insert Production Items | 7d | 2012-05-10 | 2012-05-18 | 142 | 56d |
| 144 |  | FAI Review & Approval | 4d | 2012-05-21 | 2012-05-24 | 143 | 56d |
| 145 |  | User Guide | 0d | 2012-03-12 | 2012-03-12 | 65 | 119d |
| 146 |  | Insert Design | 0d | 2012-03-12 | 2012-03-12 | 65 | 119d |
| 147 | 1.3.4.5 | **QSG** | 59d | 2012-02-23 | 2012-05-15 |  | 73d |
| 148 |  | QSG Copy | 0d | 2012-02-23 | 2012-02-23 |  | 120d |
| 149 |  | QSG Design | 4d | 2012-04-30 | 2012-05-03 | 65, 120, 148 | 73d |
| 150 |  | QSG Productions Items | 4d | 2012-05-04 | 2012-05-09 | 149 | 73d |
| 151 |  | FAI Review & Approval | 4d | 2012-05-10 | 2012-05-15 | 150 | 73d |
| 152 |  | Collateral Design | 0d | 2012-03-12 | 2012-03-12 | 65 | 109d |
| 153 |  | Label Design | 0d | 2012-03-12 | 2012-03-12 | 65 | 109d |
| 154 |  | Retail Box Design | 0d | 2012-03-12 | 2012-03-12 | 65 | 109d |
| 155 | 1.3.4.9 | **Shipping Corrugate** | 27d | 2012-04-27 | 2012-06-05 |  | 58d |
| 156 |  | Shipping Corugate Design | 0d | 2012-04-27 | 2012-04-27 | 65, 120 | 85d |
| 157 |  | Production samples | 5d | 2012-05-28 | 2012-06-01 | 137FF | 48d |
| 158 |  | FAI Review & Approval | 2d | 2012-06-04 | 2012-06-05 | 157 | 48d |
| 159 | 1.3.5 | **BOM** | 2d | 2012-03-16 | 2012-03-19 |  | 103d |
| 160 |  | Marketing Pre-lim BOM | 1d | 2012-03-16 | 2012-03-16 | 14 | 115d |
| 161 |  | Engineering Pre-lim BOM | 2d | 2012-03-16 | 2012-03-19 | 14 | 103d |
| 162 | 1.3.6 | **Pre-planning** | 2d | 2012-02-27 | 2012-02-28 |  | 127d |
| 163 |  | Pre-lim Forecast Frozen | 1d | 2012-02-27 | 2012-02-27 | 5 | 127d |
| 164 |  | Pre-lim-Forecast in Oracle | 1d | 2012-02-28 | 2012-02-28 | 163 | 127d |
| 165 | 1.3.7 | **Engineering Validation Test (EVT)** | 10d | 2012-06-01 | 2012-06-14 |  | 4d |
| 166 |  | T0 Mechanical | 1d | 2012-06-01 | 2012-06-01 | 124 | 4d |
| 167 |  | EVT prototypes 2 units | 5d | 2012-06-04 | 2012-06-08 | 112, 166 | 4d |
| 168 |  | Engineering Validation Testing | 3d | 2012-06-11 | 2012-06-13 | 167 | 4d |
| 169 |  | Approve | 1d | 2012-06-14 | 2012-06-14 | 168 | 4d |
| 170 | 1.3.8 | **Design Validation Test (DVT)** | 51d | 2012-06-15 | 2012-08-24 |  | 0d |
| 171 |  | Changes from EVT | 5d | 2012-06-15 | 2012-06-21 | 169 | 4d |
| 172 |  | T1 Mechanical | 1d | 2012-06-27 | 2012-06-27 | 130 | 0d |
| 173 |  | DVT prototypes 10 units | 5d | 2012-06-28 | 2012-07-04 | 171, 172 | 0d |
| 174 |  | Design Validation Testing | 7d | 2012-07-13 | 2012-07-26 | 173 | 11d |
| 175 | 1.3.8.5 | **PCB Qualification** | 37d | 2012-07-05 | 2012-08-24 |  | 0d |
| 176 |  | EMI | 5d | 2012-07-05 | 2012-07-11 | 173 | 0d |
| 177 |  | ESD | 0d | 2012-07-11 | 2012-07-11 | 176 | 1d |
| 178 |  | FCC | 0d | 2012-07-11 | 2012-07-11 | 177 | 32d |
| 179 |  | USB IF | 10d | 2012-07-27 | 2012-08-09 | 176 | 11d |
| 180 |  | WHQL | 11d | 2012-08-10 | 2012-08-24 | 176 | 0d |
| 181 |  | Certificate | 11d | 2012-07-12 | 2012-07-26 | 177 | 21d |
| 182 |  | Approve | 1d | 2012-07-12 | 2012-07-12 | 176, 177 | 1d |
| 183 | 1.3.9 | **Phase 2 gate** | 2d | 2012-07-13 | 2012-07-16 |  | 27d |
| 184 |  | Review & Approval | 2d | 2012-07-13 | 2012-07-16 | 54, 105, 182 | 27d |
| 185 | 1.4 | **Phase 3 (Qualification)** | 112d | 2012-03-12 A | 2012-08-15 |  | 7d |
| 186 | 1.4.1 | **Packaging** | 76d | 2012-03-12 A | 2012-06-26 |  | 43d |
| 187 |  | Die Lines (all components) | 0d | 2012-03-12 | 2012-03-12 | 65 | 105d |
| 188 | 1.4.1.2 | **Clamshell** | 20d | 2012-05-29 A | 2012-06-26 |  | 43d |
| 189 |  | Prototype Sample delivery & approval | 0d | 2012-06-11 | 2012-06-11 | 138 | 54d |
| 190 |  | Production samples (20 units) | 1d | 2012-05-29 A | 2012-06-26 | 140 | 33d |
| 191 |  | FA Review & Approval | 0d | 2012-06-26 | 2012-06-26 | 190 | 33d |
| 192 | 1.4.1.3 | **Clamshell Insert** | 0d | 2012-05-24 | 2012-05-24 |  | 56d |
| 193 |  | FA Review & Approval | 0d | 2012-05-24 | 2012-05-24 | 144 | 56d |
| 194 | 1.4.1.4 | **Collateral** | 0d | 2012-03-12 | 2012-03-12 |  | 109d |
| 195 |  | FA Review & Approval | 0d | 2012-03-12 | 2012-03-12 | 152 | 109d |
| 196 | 1.4.1.5 | **Labels** | 0d | 2012-03-12 | 2012-03-12 |  | 109d |
| 197 |  | FA Review & Approval | 0d | 2012-03-12 | 2012-03-12 | 153 | 109d |
| 198 | 1.4.1.6 | **Retail Box Artwork** | 0d | 2012-03-12 | 2012-03-12 |  | 109d |
| 199 |  | FA Review & Approval | 0d | 2012-03-12 | 2012-03-12 | 154 | 109d |
| 200 | 1.4.1.7 | **FG Box** | 0d | 2012-03-12 | 2012-03-12 |  | 109d |
| 201 |  | FA Review & Approval | 0d | 2012-03-12 | 2012-03-12 | 199 | 109d |
| 202 | 1.4.1.8 | **Shipping Corrugate** | 0d | 2012-06-05 | 2012-06-05 |  | 48d |
| 203 |  | FA Review & Approval | 0d | 2012-06-05 | 2012-06-05 | 158 | 48d |
| 204 | 1.4.1.9 | **Package Qualification** | 14d | 2012-03-13 | 2012-03-30 |  | 105d |
| 205 | 1.4.1.9.1 | **Packaging Test** | 12.5d | 2012-03-13 | 2012-03-29 |  | 105d |
| 206 |  | Testing | 12d | 2012-03-13 | 2012-03-28 | 187 | 105d |
| 207 |  | Report Review & Approval | 0.5d | 2012-03-29 | 2012-03-29 | 206 | 105d |
| 208 | 1.4.1.9.2 | **Packaging Test Sample** | 1.5d | 2012-03-29 | 2012-03-30 |  | 105d |
| 209 |  | Review & Approval | 1.5d | 2012-03-29 | 2012-03-30 | 205 | 105d |
| 210 |  | All packaging Items approved | 0d | 2012-06-26 | 2012-06-26 | 187, 191, 193, 195, 197, 199, 201, 203 | 33d |

| ID | WBS | Task | Duration | Start | Finish | Predecessors | Total float |
| --- | --- | --- | --- | --- | --- | --- | --- |
| 211 | 1.4.3 | **BOM** | 4d | 2012-05-15 | 2012-05-18 |  | 61d |
| 212 |  | Engineering PVT | 2d | 2012-05-15 | 2012-05-16 | 111 | 61d |
| 213 |  | Marketing PVT | 2d | 2012-05-17 | 2012-05-18 | 212 | 61d |
| 214 | 1.4.4 | **Production Validation Test (PVT)** | 63d | 2012-05-15 | 2012-08-09 |  | 1d |
| 215 | 1.4.4.1 | **PVT Build** | 58d | 2012-05-15 | 2012-08-02 |  | 1d |
| 216 |  | Material PO | 1d | 2012-05-15 | 2012-05-15 | 111, 123 | 43d |
| 217 |  | Build 500 functional units | 10d | 2012-07-18 | 2012-08-02 | 182, 216 | 1d |
| 218 | 1.4.4.2 | **Samples** | 4d | 2012-08-03 | 2012-08-08 |  | 1d |
| 219 |  | Marketing Sample Delivery | 4d | 2012-08-03 | 2012-08-08 | 217 | 1d |
| 220 |  | Preproduction Sample Delivery | 0d | 2012-08-08 | 2012-08-08 | 219 | 1d |
| 221 | 1.4.4.3 | **FAI (unit without Mrktg Packaging)** | 1d | 2012-08-09 | 2012-08-09 |  | 1d |
| 222 |  | Review & Approve | 1d | 2012-08-09 | 2012-08-09 | 220 | 1d |
| 223 | 1.4.4.4 | **PVT Testing** | 17d | 2012-07-05 | 2012-07-27 |  | 10d |
| 224 |  | Mechanical Test | 7d | 2012-07-05 | 2012-07-13 | 173 | 10d |
| 225 |  | Applications Compatibility Test | 0d | 2012-07-13 | 2012-07-13 | 224 | 10d |
| 226 |  | Certification / Compliance Qual | 0d | 2012-07-13 | 2012-07-13 | 225 | 10d |
| 227 |  | Product Reliability Qualification | 0d | 2012-07-13 | 2012-07-13 | 226 | 10d |
| 228 |  | Yeild Analysis | 0d | 2012-07-13 | 2012-07-13 | 227 | 10d |
| 229 |  | PVT Testing approved | 3d | 2012-07-17 | 2012-07-27 | 225, 226, 227, 228 | 10d |
| 230 | 1.4.5 | **FAI - Production Samples FG** | 1d | 2012-08-10 | 2012-08-10 |  | 1d |
| 231 |  | FA Review & Approval | 1d | 2012-08-10 | 2012-08-10 | 169, 174, 182, 210, 222, 229 | 1d |
| 232 | 1.4.6 | **CM/ODM Readiness** | 98d | 2012-03-21 | 2012-08-03 |  | 15d |
| 233 |  | Final Forecast | 1d | 2012-03-21 | 2012-03-21 | 90, 164 | 112d |
| 234 |  | Hand Off Packet | 5d | 2012-07-30 | 2012-08-03 | 217SF-1d | 15d |
| 235 |  | Material in Place for ISO (Components - PCB, Memory, Controllers, Housing) | 1d | 2012-07-12 | 2012-07-12 | 161, 177 | 21d |
| 236 |  | PO for ISO Builds | 1d | 2012-07-13 | 2012-07-13 | 97, 108, 235 | 21d |
| 237 |  | W/O | 1d | 2012-07-16 | 2012-07-16 | 236 | 24d |
| 238 |  | ISO Builds | 1d | 2012-07-17 | 2012-07-17 | 213, 237 | 24d |
| 239 |  | Ramp-up | 1d | 2012-07-30 | 2012-07-30 | 94, 229, 238 | 16d |
| 240 |  | Work Sheet Approved | 1d | 2012-07-31 | 2012-07-31 | 239 | 16d |
| 241 | 1.4.7 | **BOM** | 1d | 2012-08-13 | 2012-08-13 |  | 7d |
| 242 |  | Release Notes for Engineering BOM and Marketing BOM | 1d | 2012-08-13 | 2012-08-13 | 229, 231 | 7d |
| 243 | 1.4.8 | **Phase 3 gate** | 2d | 2012-08-14 | 2012-08-15 |  | 7d |
| 244 |  | Review & Approve | 2d | 2012-08-14 | 2012-08-15 | 184, 231, 240, 242 | 7d |
| 245 | 1.5 | **Phase 4 (Production)** | 9d | 2012-08-10 | 2012-08-23 |  | 1d |
| 246 |  | FG Launch Buiild | 0d | 2012-08-10 | 2012-08-10 | 213, 229, 231, 235, 236 | 1d |
| 247 |  | Taiwan | 3d | 2012-08-13 | 2012-08-15 | 246 | 1d |
| 248 |  | NA | 3d | 2012-08-21 | 2012-08-23 | 247 | 1d |
| 249 |  | EU | 3d | 2012-08-16 | 2012-08-20 | 247 | 4d |
| 250 |  | Mass-Production | 0d | 2012-08-20 | 2012-08-20 | 249 | 4d |

## Version 2 (saved 2012-03-15, file USB Flash Drive_03152012_prefinal.mpp)

Last finish 2012-08-24 → 2012-08-30 (+6d). Complete tasks 37 → 15.

Added:

| ID | Task | Duration | Start | Finish | Resources |
| --- | --- | --- | --- | --- | --- |
| 217 | NAND | 1d | 2012-05-29 | 2012-05-29 | NAND supplier [80000%] |
| 218 | PCB | 1d | 2012-05-29 | 2012-05-29 | PCB supplier [10000%] |
| 219 | Capacitors, resistors, diodes, transistors, etc | 1d | 2012-05-29 | 2012-05-29 | Passives supplier |
| 220 | Controller | 1d | 2012-05-29 | 2012-05-29 | CONtroller supplier [10000%] |
| 221 | Housing | 1d | 2012-05-29 | 2012-05-29 | Housing supplier [10000%] |
| 222 | Other | 1d | 2012-05-29 | 2012-05-29 | Other supplier [10000%] |
| 243 | NAND | 1d | 2012-07-19 | 2012-07-19 | NAND supplier |
| 244 | PCB | 1d | 2012-07-19 | 2012-07-19 | PCB supplier |
| 245 | Capacitors, resistors, diodes, transistors, etc | 1d | 2012-07-19 | 2012-07-19 | Passives supplier |
| 246 | Controller | 1d | 2012-07-19 | 2012-07-19 | CONtroller supplier |
| 247 | Housing | 1d | 2012-07-19 | 2012-07-19 | Housing supplier |
| 248 | Other | 1d | 2012-07-19 | 2012-07-19 | Other supplier |

Changed:

| ID | Task | Start | Finish | Duration | Complete | Total float |
| --- | --- | --- | --- | --- | --- | --- |
| 1 | **USB Flash Drive** |  | 2012-08-24 → 2012-08-30 (+6d) | 132d → 136d | 12% → 4% |  |
| 8 | **Phase 1 (Planning)** |  | 2012-06-12 A → 2012-06-12 |  | 100% → 28% | none → 53d |
| 10 | **Requirements** |  | 2012-05-31 A → 2012-05-31 |  | 100% → 40% | none → 0d |
| 15 | **Industrial Design** | 2012-03-02 A → 2012-03-02 | 2012-03-26 A → 2012-03-26 |  | 100% → 0% | none → 0d |
| 16 | Contractor Selection | 2012-03-02 A → 2012-03-02 | 2012-03-22 A → 2012-03-22 |  | 100% → 0% | none → 0d |
| 17 | Initial Industrial Design | 2012-03-23 A → 2012-03-23 | 2012-03-23 A → 2012-03-23 |  | 100% → 0% | none → 0d |
| 18 | Review | 2012-03-26 A → 2012-03-26 | 2012-03-26 A → 2012-03-26 |  | 100% → 0% | none → 0d |
| 19 | **Outsourcing - Suppliers/Partners Selection** |  | 2012-05-31 A → 2012-05-31 |  | 100% → 26% | none → 0d |
| 20 | **RFQ process** |  | 2012-05-31 A → 2012-05-31 |  | 100% → 26% | none → 0d |
| 22 | Suppliers/Partners Review | 2012-03-05 A → 2012-03-05 | 2012-03-27 A → 2012-03-27 |  | 100% → 0% | none → 0d |
| 23 | Issue RFQs including PRD | 2012-03-28 A → 2012-03-28 | 2012-03-28 A → 2012-03-28 |  | 100% → 0% | none → 0d |
| 24 | **ODM Quote completed** | 2012-03-29 A → 2012-03-29 | 2012-05-15 A → 2012-05-15 |  | 100% → 0% | none → 0d |
| 25 | Review Financial Terms | 2012-03-29 A → 2012-03-29 | 2012-03-29 A → 2012-03-29 |  | 100% → 0% | none → 32d |
| 26 | Review Technical Capabilities | 2012-03-30 A → 2012-03-30 | 2012-05-14 A → 2012-05-14 |  | 100% → 0% | none → 0d |
| 27 | Review Production Capabilities | 2012-03-29 A → 2012-03-29 | 2012-03-29 A → 2012-03-29 |  | 100% → 0% | none → 32d |
| 28 | ODM/CM Selection | 2012-05-15 A → 2012-05-15 | 2012-05-15 A → 2012-05-15 |  | 100% → 0% | none → 0d |
| 29 | Supplier Kick off Meeting | 2012-05-16 A → 2012-05-16 | 2012-05-29 A → 2012-05-29 |  | 100% → 0% | none → 0d |
| 36 | **Mechanical Manufacturing (Shell/Housing)** | 2012-05-30 A → 2012-05-30 | 2012-05-31 A → 2012-05-31 |  | 100% → 0% | none → 0d |
| 37 | Review | 2012-05-30 A → 2012-05-30 | 2012-05-30 A → 2012-05-30 |  | 100% → 0% | none → 0d |
| 38 | Contractor Selection | 2012-05-30 A → 2012-05-30 | 2012-05-30 A → 2012-05-30 |  | 100% → 0% | none → 0d |
| 39 | Kick off Meeting | 2012-05-31 A → 2012-05-31 | 2012-05-31 A → 2012-05-31 |  | 100% → 0% | none → 0d |
| 40 | **Schedule** | 2012-03-19 A → 2012-03-19 | 2012-06-06 A → 2012-06-06 |  | 100% → 0% | none → 0d |
| 41 | Set-up | 2012-03-19 A → 2012-03-19 | 2012-03-28 A → 2012-03-28 |  | 100% → 0% | none → 46d |
| 42 | Review | 2012-06-01 A → 2012-06-01 | 2012-06-06 A → 2012-06-06 |  | 100% → 0% | none → 0d |
| 43 | Approval | 2012-06-06 A → 2012-06-06 | 2012-06-06 A → 2012-06-06 |  | 100% → 0% | none → 0d |
| 44 | **BOMs/Routings** | 2012-05-17 A → 2012-05-17 | 2012-05-28 A → 2012-05-28 |  | 100% → 0% | none → 60d |
| 45 | Engineering PN Generation | 2012-05-18 A → 2012-05-18 | 2012-05-18 A → 2012-05-18 |  | 100% → 0% | none → 66d |
| 46 | Marketing BOM (SKU) Initial Status | 2012-05-28 A → 2012-05-28 | 2012-05-28 A → 2012-05-28 |  | 100% → 0% | none → 60d |
| 47 | Manufacturing BOM (Technical) Initial Status | 2012-05-17 A → 2012-05-17 | 2012-05-17 A → 2012-05-17 |  | 100% → 0% | none → 67d |
| 48 | **Financial Model** | 2012-03-01 A → 2012-03-01 | 2012-06-08 A → 2012-06-08 |  | 100% → 0% | none → 53d |
| 49 | Product Development Budget | 2012-06-07 A → 2012-06-07 | 2012-06-07 A → 2012-06-07 |  | 100% → 0% | none → 53d |
| 50 | Product Cost | 2012-05-29 A → 2012-05-29 | 2012-05-29 A → 2012-05-29 |  | 100% → 0% | none → 60d |
| 51 | Marketing Plan | 2012-03-01 A → 2012-03-01 | 2012-03-01 A → 2012-03-01 |  | 100% → 0% | none → 123d |
| 52 | ROI/Revenue Projection | 2012-06-08 A → 2012-06-08 | 2012-06-08 A → 2012-06-08 |  | 100% → 0% | none → 53d |
| 53 | **Phase 1 Gate** | 2012-06-11 A → 2012-06-11 | 2012-06-12 A → 2012-06-12 |  | 100% → 0% | none → 53d |
| 54 | Review & Approval | 2012-06-11 A → 2012-06-11 | 2012-06-12 A → 2012-06-12 |  | 100% → 0% | none → 53d |
| 55 | **Phase 2 (Development)** | 2012-02-23 A | 2012-08-24 → 2012-08-30 (+6d) | 132d → 136d | 0% → 1% |  |
| 56 | **Documentation** |  | 2012-06-11 → 2012-06-12 (+1d) | 72d → 73d |  | 23d → 14d |
| 57 | **Final Product spec to suppliers / Vendors** | 2012-03-21 → 2012-03-22 (+1d) | 2012-03-23 → 2012-03-26 (+3d) |  |  | 10d → 0d |
| 58 | Develop Spec | 2012-03-21 → 2012-03-22 (+1d) | 2012-03-21 → 2012-03-22 (+1d) |  |  | 10d → 0d |
| 59 | Prepare document | 2012-03-22 → 2012-03-23 (+1d) | 2012-03-22 → 2012-03-23 (+1d) |  |  | 10d → 0d |
| 60 | Review & Approve | 2012-03-23 → 2012-03-26 (+3d) | 2012-03-23 → 2012-03-26 (+3d) |  |  | 10d → 0d |
| 61 | **Packaging Plan** |  | 2012-03-12 → 2012-03-21 (+9d) | 7d → 14d |  | 69d → 64d |
| 65 | Review & Approved | 2012-03-12 → 2012-03-21 (+9d) | 2012-03-12 → 2012-03-21 (+9d) |  |  | 69d → 64d |
| 66 | **Product Qual Plan** |  | 2012-05-18 → 2012-05-23 (+5d) | 46d → 49d |  | 65d → 66d |
| 67 | **Compatibility Test Plan** |  | 2012-05-18 → 2012-03-23 (-56d) | 46d → 6d |  | 65d → 109d |
| 69 | Publish Plan | 2012-03-19 → 2012-03-20 (+1d) | 2012-03-19 → 2012-03-20 (+1d) |  |  | 65d → 109d |
| 70 | Review & Approval |  | 2012-05-18 → 2012-03-23 (-56d) |  |  | 65d → 109d |
| 71 | **Reliability Plan** | 2012-03-16 → 2012-03-27 (+11d) | 2012-03-20 → 2012-05-23 (+64d) | 3d → 42d |  | 108d → 66d |
| 72 | Prepare document | 2012-03-16 → 2012-03-27 (+11d) | 2012-03-16 → 2012-03-27 (+11d) |  |  | 108d → 66d |
| 73 | Publish Plan | 2012-03-19 → 2012-05-22 (+64d) | 2012-03-19 → 2012-05-22 (+64d) |  |  | 108d → 66d |
| 74 | Review & Approval | 2012-03-20 → 2012-05-23 (+64d) | 2012-03-20 → 2012-05-23 (+64d) |  |  | 108d → 66d |
| 75 | **Compliance/Certification Plan** | 2012-03-16 → 2012-03-26 (+10d) | 2012-03-20 → 2012-05-21 (+62d) | 3d → 41d |  | 108d → 68d |
| 76 | Prepare document | 2012-03-16 → 2012-03-26 (+10d) | 2012-03-16 → 2012-03-26 (+10d) |  |  | 108d → 68d |
| 77 | Publish Plan | 2012-03-19 → 2012-05-15 (+57d) | 2012-03-19 → 2012-05-15 (+57d) |  |  | 108d → 68d |
| 78 | Review & Approval | 2012-03-20 → 2012-05-17 (+58d) | 2012-03-20 → 2012-05-21 (+62d) | 1d → 2d |  | 108d → 68d |
| 79 | **Packaging Qual Plan** | 2012-03-16 → 2012-03-22 (+6d) | 2012-03-22 → 2012-04-02 (+11d) | 5d → 8d |  | 106d → 103d |
| 80 | Prepare document | 2012-03-16 → 2012-03-22 (+6d) | 2012-03-16 → 2012-03-22 (+6d) |  |  | 106d → 103d |
| 81 | Publish Plan | 2012-03-19 → 2012-03-23 (+4d) | 2012-03-21 → 2012-03-27 (+6d) |  |  | 106d → 103d |
| 82 | Review & Approval | 2012-03-22 → 2012-04-02 (+11d) | 2012-03-22 → 2012-04-02 (+11d) |  |  | 106d → 103d |
| 83 | **QA Plan (IQC, OQC, OQRM, etc)** | 2012-03-16 → 2012-03-21 (+5d) | 2012-03-20 → 2012-04-02 (+13d) | 3d → 9d |  | 108d → 103d |
| 84 | Prepare document | 2012-03-16 → 2012-03-21 (+5d) | 2012-03-16 → 2012-03-21 (+5d) |  |  | 108d → 103d |
| 85 | Publish Plan | 2012-03-19 → 2012-03-23 (+4d) | 2012-03-19 → 2012-03-23 (+4d) |  |  | 108d → 103d |
| 86 | Review & Approval | 2012-03-20 → 2012-04-02 (+13d) | 2012-03-20 → 2012-04-02 (+13d) |  |  | 108d → 103d |
| 87 | **Production Plan** | 2012-03-16 → 2012-03-20 (+4d) | 2012-03-20 → 2012-03-22 (+2d) |  |  | 46d → 35d |
| 88 | Prepare document | 2012-03-16 → 2012-03-20 (+4d) | 2012-03-16 → 2012-03-20 (+4d) |  |  | 46d → 35d |
| 89 | Publish Plan | 2012-03-19 → 2012-03-21 (+2d) | 2012-03-19 → 2012-03-21 (+2d) |  |  | 46d → 35d |
| 90 | Review & Approval | 2012-03-20 → 2012-03-22 (+2d) | 2012-03-20 → 2012-03-22 (+2d) |  |  | 46d → 35d |
| 91 | **Production Test Plan** | 2012-03-16 → 2012-03-19 (+3d) | 2012-03-20 → 2012-03-26 (+6d) | 3d → 6d |  | 46d → 33d |
| 92 | Prepare document | 2012-03-16 → 2012-03-19 (+3d) | 2012-03-16 → 2012-03-19 (+3d) |  |  | 46d → 34d |

| ID | Task | Start | Finish | Duration | Complete | Total float |
| --- | --- | --- | --- | --- | --- | --- |
| 93 | Publish Plan | 2012-03-19 → 2012-03-22 (+3d) | 2012-03-19 → 2012-03-22 (+3d) |  |  | 46d → 33d |
| 94 | Review & Approval | 2012-03-20 → 2012-03-26 (+6d) | 2012-03-20 → 2012-03-26 (+6d) |  |  | 46d → 33d |
| 95 | **Product Test** | 2012-03-21 → 2012-03-27 (+6d) | 2012-06-11 → 2012-06-12 (+1d) | 59d → 56d |  | 54d → 57d |
| 96 | Product Test Specifications | 2012-05-31 → 2012-06-01 (+1d) | 2012-05-31 → 2012-06-01 (+1d) |  |  | 44d → 47d |
| 97 | Test Equipment | 2012-06-01 → 2012-06-04 (+3d) | 2012-06-11 → 2012-06-12 (+1d) |  |  | 44d → 47d |
| 98 | **Pre-lim Process** | 2012-03-22 → 2012-03-28 (+6d) | 2012-03-26 → 2012-03-28 (+2d) | 3d → 1d |  | 109d → 111d |
| 99 | Publish Plan | 2012-03-22 → 2012-03-28 (+6d) | 2012-03-26 → 2012-03-28 (+2d) | 2d → 1d |  | 109d → 111d |
| 100 | Review & Approval | 2012-03-26 → 2012-03-28 (+2d) | 2012-03-26 → 2012-03-28 (+2d) |  |  | 109d → 111d |
| 101 | **Pre-lim Program** | 2012-03-21 → 2012-03-27 (+6d) | 2012-03-23 → 2012-03-27 (+4d) | 3d → 1d |  | 110d → 112d |
| 102 | Publish Plan | 2012-03-21 → 2012-03-27 (+6d) | 2012-03-23 → 2012-03-27 (+4d) | 2d → 1d |  | 110d → 112d |
| 103 | Review & Approval | 2012-03-23 → 2012-03-27 (+4d) | 2012-03-23 → 2012-03-27 (+4d) |  |  | 110d → 112d |
| 104 | All qual plans prepared | 2012-03-22 → 2012-03-27 (+5d) | 2012-03-22 → 2012-03-27 (+5d) |  |  | 111d → 112d |
| 105 | All Qual Plans Approved | 2012-05-21 → 2012-05-24 (+3d) | 2012-05-21 → 2012-05-24 (+3d) |  |  | 65d → 66d |
| 106 | **PCB** | 2012-03-26 → 2012-03-27 (+1d) | 2012-05-24 → 2012-06-07 (+14d) | 44d → 53d |  | 10d → 0d |
| 107 | Schematic Design | 2012-03-26 → 2012-03-27 (+1d) | 2012-04-04 → 2012-04-05 (+1d) |  |  | 10d → 0d |
| 108 | PCB Layout | 2012-04-05 → 2012-04-06 (+1d) | 2012-05-04 → 2012-05-07 (+3d) |  |  | 10d → 0d |
| 109 | Design Review | 2012-05-07 → 2012-05-08 (+1d) | 2012-05-09 → 2012-05-10 (+1d) |  |  | 10d → 0d |
| 110 | Design For Manufacturability (DFM) - PCB | 2012-05-10 → 2012-05-21 (+11d) | 2012-05-11 → 2012-05-25 (+14d) | 2d → 4d |  | 10d → 0d |
| 111 | Approve | 2012-05-14 → 2012-05-28 (+14d) | 2012-05-14 → 2012-05-28 (+14d) |  |  | 10d → 0d |
| 112 | PCB Fabrication | 2012-05-15 → 2012-05-29 (+14d) | 2012-05-24 → 2012-06-07 (+14d) |  |  | 10d → 0d |
| 113 | **Housing** |  | 2012-06-26 → 2012-07-02 (+6d) | 73d → 77d |  |  |
| 130 | Housing Approved | 2012-06-22 → 2012-06-28 (+6d) | 2012-06-26 → 2012-07-02 (+6d) |  |  |  |
| 145 | User Guide | 2012-03-12 → 2012-03-21 (+9d) | 2012-03-12 → 2012-03-21 (+9d) |  |  | 119d → 116d |
| 146 | Insert Design | 2012-03-12 → 2012-03-21 (+9d) | 2012-03-12 → 2012-03-21 (+9d) |  |  | 119d → 116d |
| 152 | Collateral Design | 2012-03-12 → 2012-03-21 (+9d) | 2012-03-12 → 2012-03-21 (+9d) |  |  | 109d → 106d |
| 153 | Label Design | 2012-03-12 → 2012-03-21 (+9d) | 2012-03-12 → 2012-03-21 (+9d) |  |  | 109d → 106d |
| 154 | Retail Box Design | 2012-03-12 → 2012-03-21 (+9d) | 2012-03-12 → 2012-03-21 (+9d) |  |  | 109d → 106d |
| 162 | **Pre-planning** | 2012-02-27 A | 2012-02-28 A |  | 0% → 100% | 127d → none |
| 163 | Pre-lim Forecast Frozen | 2012-02-27 A | 2012-02-27 A |  | 0% → 100% | 127d → none |
| 164 | Pre-lim-Forecast in Oracle | 2012-02-28 A | 2012-02-28 A |  | 0% → 100% | 127d → none |
| 165 | **Engineering Validation Test (EVT)** |  | 2012-06-14 → 2012-06-21 (+7d) | 10d → 15d |  | 4d → 0d |
| 167 | EVT prototypes 2 units | 2012-06-04 → 2012-06-08 (+4d) | 2012-06-08 → 2012-06-15 (+7d) |  |  | 4d → 0d |
| 168 | Engineering Validation Testing | 2012-06-11 → 2012-06-18 (+7d) | 2012-06-13 → 2012-06-20 (+7d) |  |  | 4d → 0d |
| 169 | Approve | 2012-06-14 → 2012-06-21 (+7d) | 2012-06-14 → 2012-06-21 (+7d) |  |  | 4d → 0d |
| 170 | **Design Validation Test (DVT)** | 2012-06-15 → 2012-06-22 (+7d) | 2012-08-24 → 2012-08-30 (+6d) | 51d → 50d |  |  |
| 171 | Changes from EVT | 2012-06-15 → 2012-06-22 (+7d) | 2012-06-21 → 2012-07-03 (+12d) |  |  | 4d → 0d |
| 172 | T1 Mechanical | 2012-06-27 → 2012-07-03 (+6d) | 2012-06-27 → 2012-07-03 (+6d) |  |  |  |
| 173 | DVT prototypes 10 units | 2012-06-28 → 2012-07-04 (+6d) | 2012-07-04 → 2012-07-10 (+6d) |  |  |  |
| 174 | Design Validation Testing | 2012-07-13 → 2012-07-19 (+6d) | 2012-07-26 → 2012-08-01 (+6d) |  |  |  |
| 175 | **PCB Qualification** | 2012-07-05 → 2012-07-11 (+6d) | 2012-08-24 → 2012-08-30 (+6d) |  |  |  |
| 176 | EMI | 2012-07-05 → 2012-07-11 (+6d) | 2012-07-11 → 2012-07-17 (+6d) |  |  |  |
| 177 | ESD | 2012-07-11 → 2012-07-17 (+6d) | 2012-07-11 → 2012-07-17 (+6d) |  |  |  |
| 178 | FCC | 2012-07-11 → 2012-07-17 (+6d) | 2012-07-11 → 2012-07-17 (+6d) |  |  |  |
| 179 | USB IF | 2012-07-27 → 2012-08-02 (+6d) | 2012-08-09 → 2012-08-15 (+6d) |  |  |  |
| 180 | WHQL | 2012-08-10 → 2012-08-16 (+6d) | 2012-08-24 → 2012-08-30 (+6d) |  |  |  |
| 181 | Certificate | 2012-07-12 → 2012-07-18 (+6d) | 2012-07-26 → 2012-08-01 (+6d) |  |  |  |
| 182 | Approve | 2012-07-12 → 2012-07-18 (+6d) | 2012-07-12 → 2012-07-18 (+6d) |  |  |  |
| 183 | **Phase 2 gate** | 2012-07-13 → 2012-07-19 (+6d) | 2012-07-16 → 2012-07-20 (+4d) |  |  |  |
| 184 | Review & Approval | 2012-07-13 → 2012-07-19 (+6d) | 2012-07-16 → 2012-07-20 (+4d) |  |  |  |
| 185 | **Phase 3 (Qualification)** | 2012-03-12 A → 2012-03-21 A (+9d) | 2012-08-15 → 2012-08-21 (+6d) | 112d → 109d |  |  |
| 186 | **Packaging** | 2012-03-12 A → 2012-03-21 A (+9d) |  | 76d → 69d |  | 43d → 47d |
| 187 | Die Lines (all components) | 2012-03-12 → 2012-03-21 (+9d) | 2012-03-12 → 2012-03-21 (+9d) |  |  | 105d → 102d |
| 194 | **Collateral** | 2012-03-12 → 2012-03-21 (+9d) | 2012-03-12 → 2012-03-21 (+9d) |  |  | 109d → 106d |
| 195 | FA Review & Approval | 2012-03-12 → 2012-03-21 (+9d) | 2012-03-12 → 2012-03-21 (+9d) |  |  | 109d → 106d |
| 196 | **Labels** | 2012-03-12 → 2012-03-21 (+9d) | 2012-03-12 → 2012-03-21 (+9d) |  |  | 109d → 106d |
| 197 | FA Review & Approval | 2012-03-12 → 2012-03-21 (+9d) | 2012-03-12 → 2012-03-21 (+9d) |  |  | 109d → 106d |
| 198 | **Retail Box Artwork** | 2012-03-12 → 2012-03-21 (+9d) | 2012-03-12 → 2012-03-21 (+9d) |  |  | 109d → 106d |
| 199 | FA Review & Approval | 2012-03-12 → 2012-03-21 (+9d) | 2012-03-12 → 2012-03-21 (+9d) |  |  | 109d → 106d |
| 200 | **FG Box** | 2012-03-12 → 2012-03-21 (+9d) | 2012-03-12 → 2012-03-21 (+9d) |  |  | 109d → 106d |
| 201 | FA Review & Approval | 2012-03-12 → 2012-03-21 (+9d) | 2012-03-12 → 2012-03-21 (+9d) |  |  | 109d → 106d |
| 204 | **Package Qualification** | 2012-03-13 → 2012-03-22 (+9d) | 2012-03-30 → 2012-04-10 (+11d) |  |  | 105d → 102d |
| 205 | **Packaging Test** | 2012-03-13 → 2012-03-22 (+9d) | 2012-03-29 → 2012-04-09 (+11d) |  |  | 105d → 102d |
| 206 | Testing | 2012-03-13 → 2012-03-22 (+9d) | 2012-03-28 → 2012-04-06 (+9d) |  |  | 105d → 102d |
| 207 | Report Review & Approval | 2012-03-29 → 2012-04-09 (+11d) | 2012-03-29 → 2012-04-09 (+11d) |  |  | 105d → 102d |
| 208 | **Packaging Test Sample** | 2012-03-29 → 2012-04-09 (+11d) | 2012-03-30 → 2012-04-10 (+11d) |  |  | 105d → 102d |
| 209 | Review & Approval | 2012-03-29 → 2012-04-09 (+11d) | 2012-03-30 → 2012-04-10 (+11d) |  |  | 105d → 102d |
| 211 | **BOM** | 2012-05-15 → 2012-06-06 (+22d) | 2012-05-18 → 2012-06-12 (+25d) | 4d → 5d |  | 61d → 46d |
| 212 | Engineering PVT | 2012-05-15 → 2012-06-06 (+22d) | 2012-05-16 → 2012-06-07 (+22d) |  |  | 61d → 46d |
| 213 | Marketing PVT | 2012-05-17 → 2012-06-11 (+25d) | 2012-05-18 → 2012-06-12 (+25d) |  |  | 61d → 48d |
| 214 | **Production Validation Test (PVT)** | 2012-05-15 → 2012-05-29 (+14d) | 2012-08-09 → 2012-08-15 (+6d) | 63d → 57d |  |  |

| ID | Task | Start | Finish | Duration | Total float | Other |
| --- | --- | --- | --- | --- | --- | --- |
| 215 | **PVT Build** | 2012-05-15 → 2012-05-29 (+14d) | 2012-08-02 → 2012-08-08 (+6d) | 58d → 52d |  |  |
| 216 | **Material PO** | 2012-05-15 → 2012-05-29 (+14d) | 2012-05-15 → 2012-05-29 (+14d) |  | 43d → 37d |  |
| 223 | Build 100 functional units | 2012-07-18 → 2012-07-24 (+6d) | 2012-08-02 → 2012-08-08 (+6d) |  |  | was named Build 500 functional units |
| 224 | **Samples** | 2012-08-03 → 2012-08-09 (+6d) | 2012-08-08 → 2012-08-14 (+6d) |  |  |  |
| 225 | Marketing Sample Delivery | 2012-08-03 → 2012-08-09 (+6d) | 2012-08-08 → 2012-08-14 (+6d) |  |  |  |
| 226 | Preproduction Sample Delivery | 2012-08-08 → 2012-08-14 (+6d) | 2012-08-08 → 2012-08-14 (+6d) |  |  |  |
| 227 | **FAI (unit without Mrktg Packaging)** | 2012-08-09 → 2012-08-15 (+6d) | 2012-08-09 → 2012-08-15 (+6d) |  |  |  |
| 228 | Review & Approve | 2012-08-09 → 2012-08-15 (+6d) | 2012-08-09 → 2012-08-15 (+6d) |  |  |  |
| 229 | **PVT Testing** | 2012-07-05 → 2012-07-11 (+6d) | 2012-07-27 → 2012-08-02 (+6d) |  |  |  |
| 230 | Mechanical Test | 2012-07-05 → 2012-07-11 (+6d) | 2012-07-13 → 2012-07-19 (+6d) |  | 10d → 11d |  |
| 231 | Applications Compatibility Test | 2012-07-13 → 2012-07-19 (+6d) | 2012-07-13 → 2012-07-19 (+6d) |  | 10d → 11d |  |
| 232 | Certification / Compliance Qual | 2012-07-13 → 2012-07-19 (+6d) | 2012-07-13 → 2012-07-19 (+6d) |  | 10d → 11d |  |
| 233 | Product Reliability Qualification | 2012-07-13 → 2012-07-19 (+6d) | 2012-07-13 → 2012-07-19 (+6d) |  | 10d → 11d |  |
| 234 | Yeild Analysis | 2012-07-13 → 2012-07-19 (+6d) | 2012-07-13 → 2012-07-19 (+6d) |  | 10d → 11d |  |
| 235 | PVT Testing approved | 2012-07-17 → 2012-07-23 (+6d) | 2012-07-27 → 2012-08-02 (+6d) |  |  |  |
| 236 | **FAI - Production Samples FG** | 2012-08-10 → 2012-08-16 (+6d) | 2012-08-10 → 2012-08-16 (+6d) |  |  |  |
| 237 | FA Review & Approval | 2012-08-10 → 2012-08-16 (+6d) | 2012-08-10 → 2012-08-16 (+6d) |  |  |  |
| 238 | **CM/ODM Readiness** | 2012-03-21 → 2012-03-23 (+2d) | 2012-08-03 → 2012-08-10 (+7d) | 98d → 101d | 15d → 14d |  |
| 239 | Final Forecast | 2012-03-21 → 2012-03-23 (+2d) | 2012-03-21 → 2012-03-23 (+2d) |  | 112d → 114d |  |
| 240 | Hand Off Packet | 2012-07-30 → 2012-08-06 (+7d) | 2012-08-03 → 2012-08-10 (+7d) |  | 15d → 14d |  |
| 241 | Materials locked in for ISO (Components - PCB, Memory, Controllers, Housing) | 2012-07-12 → 2012-07-18 (+6d) | 2012-07-12 → 2012-07-18 (+6d) |  |  | was named Material in Place for ISO (Components - PCB, Memory, Controllers, Housing) |
| 242 | **PO for ISO Builds** | 2012-07-13 → 2012-07-19 (+6d) | 2012-07-13 → 2012-07-19 (+6d) |  |  |  |
| 249 | W/O | 2012-07-16 → 2012-07-20 (+4d) | 2012-07-16 → 2012-07-20 (+4d) |  |  |  |
| 250 | ISO Builds (10,000pcs) | 2012-07-17 → 2012-07-23 (+6d) | 2012-07-17 → 2012-07-23 (+6d) |  |  | was named ISO Builds |
| 251 | Ramp-up | 2012-07-30 → 2012-08-03 (+4d) | 2012-07-30 → 2012-08-03 (+4d) |  |  |  |
| 252 | Work Sheet Approved | 2012-07-31 → 2012-08-06 (+6d) | 2012-07-31 → 2012-08-06 (+6d) |  |  |  |
| 253 | **BOM** | 2012-08-13 → 2012-08-17 (+4d) | 2012-08-13 → 2012-08-17 (+4d) |  |  |  |
| 254 | Release Notes for Engineering BOM and Marketing BOM | 2012-08-13 → 2012-08-17 (+4d) | 2012-08-13 → 2012-08-17 (+4d) |  |  |  |
| 255 | **Phase 3 gate** | 2012-08-14 → 2012-08-20 (+6d) | 2012-08-15 → 2012-08-21 (+6d) |  |  |  |
| 256 | Review & Approve | 2012-08-14 → 2012-08-20 (+6d) | 2012-08-15 → 2012-08-21 (+6d) |  |  |  |
| 257 | **Phase 4 (Production)** | 2012-08-10 → 2012-08-16 (+6d) | 2012-08-23 → 2012-08-29 (+6d) |  |  |  |
| 258 | FG Launch Buiild | 2012-08-10 → 2012-08-16 (+6d) | 2012-08-10 → 2012-08-16 (+6d) |  |  |  |
| 259 | Taiwan | 2012-08-13 → 2012-08-17 (+4d) | 2012-08-15 → 2012-08-21 (+6d) |  |  |  |
| 260 | NA | 2012-08-21 → 2012-08-27 (+6d) | 2012-08-23 → 2012-08-29 (+6d) |  |  |  |
| 261 | EU | 2012-08-16 → 2012-08-22 (+6d) | 2012-08-20 → 2012-08-24 (+4d) |  |  |  |
| 262 | Mass-Production | 2012-08-20 → 2012-08-24 (+4d) | 2012-08-20 → 2012-08-24 (+4d) |  |  |  |
